# RICH1 HPD Mounting and IInstallation

Schedule from GanttProject, 2006-12-01 to 2007-04-20.
LHCb RICH1

## Calendars

- Project calendar: Mon-Fri working; Sat-Sun off.

## Schedule

| ID | Task | Duration | Start | Finish |
| --- | --- | --- | --- | --- |
| 1 | U Channels - Manufacture | 18d | 2006-12-01 | 2006-12-26 |
| 2 | U Channels - Annodize 28 | 9d | 2006-12-27 | 2007-01-08 |
| 3 | U Channels Annodize 4 | 4d | 2007-02-19 | 2007-02-22 |
| 4 | Rungs - Alterations | 5d | 2007-01-02 | 2007-01-08 |
| 5 | End Pieces - Manufacture 10 | 4d | 2007-01-05 | 2007-01-10 |
| 6 | End Pieces - Manufacture 22 | 13d | 2007-01-15 | 2007-01-31 |
| 7 | End Pieces - Annodize 22 | 4d | 2007-02-05 | 2007-02-08 |
| 8 | End Pieces Swap in CERN | 4d | 2007-02-12 | 2007-02-15 |
| 9 | End Pieces Annodize 10 | 4d | 2007-02-19 | 2007-02-22 |
| 10 | Adapter Plate - Manufacture 2 | 1d | 2007-01-11 | 2007-01-11 |
| 11 | Adapter Plate - Manufacture 12 | 5d | 2007-01-22 | 2007-01-26 |
| 12 | Ladder Assembly - 5 to complete top half | 2d | 2007-01-16 | 2007-01-17 |
| 13 | Ladder Assembly - 9 to complete all | 1d | 2007-02-26 | 2007-02-26 |
| 14 | Top HPD Frame - Design | 22d | 2006-12-20 | 2007-01-18 |
| 15 | Top HPD Frame - Procurement and Delivery | 9d | 2007-01-22 | 2007-02-01 |
| 16 | Top HPD Frame - Manufacture | 24d | 2007-02-05 | 2007-03-08 |
| 17 | Ladder Dressing - Top Crate 7 | 27d | 2007-02-01 | 2007-03-09 |
| 18 | Ladder Dressing - Bottom Crate 7 | 24d | 2007-03-12 | 2007-04-12 |
| 19 | Ladder Dressing - Spare 2 | 5d | 2007-04-16 | 2007-04-20 |
| 20 | Patch Panels | 27d | 2007-02-01 | 2007-03-09 |
| 21 | Cable Guides | 27d | 2007-02-01 | 2007-03-09 |
